# M0004

Schedule from MS Project, 2016-09-05 to 2019-05-14.
rmbbpublic@comcast.net
Entire work, Power Operational Intelligence ("PowerOpI") PowerQueryTool / Copyright (c) 2020 Richard M. Bixler / All Rights Reserved / rmbpublic@comcast.net / www.softtoyssoftware.com

## Calendars

- Standard-17: Mon-Fri 08:00-12:00, 13:00-17:00; Sat-Sun off.

## Resources

| Resource |
| --- |
| Company-US |
| JDM-US |
| JDM-Asia |
| Standard |

## Schedule

| ID | WBS | Task | Type | Duration | Start | Finish | Predecessors | Total slack | Free slack | Constraint | Resources | Work | Text14 |
| --- | --- | --- | --- | --- | --- | --- | --- | --- | --- | --- | --- | --- | --- |
| 1 | 1 | Last ModuleTaskUID | milestone | 0d | 2016-09-05 | 2016-09-05 |  | 1129d |  |  |  |  | P000100022 |
| 2 | 2 | M0004 ModuleName "Europa-Jun" | milestone | 0d | 2016-09-05 | 2016-09-05 |  | 1129d |  |  |  |  | P000100023 |
| 4 | 3 | **Links In** |  | 668d | 2016-09-05 | 2019-03-27 |  | 461d |  |  |  | 7560h | P000100024 |
| 5 | 3.1 | Begin Funded Work | milestone | 0d | 2018-01-01 | 2018-01-01 |  | 1d | 0d | start no earlier than 2018-01-01 |  |  |  |
| 6 | 3.2 | Begin JDM Funded Work | milestone | 0d | 2018-01-01 | 2018-01-01 | 5 | 428d | 0d |  | JDM-Asia |  | P000100025 |
| 8 | 3.3 | Intel Skylake Production |  | 561d | 2017-02-01 | 2019-03-27 |  | 461d |  | start no earlier than 2017-02-01 | Standard | 4488h | P000100026 |
| 9 | 3.4 | Intel Cascade Lake ES2 Avail Range |  | 130d | 2018-02-15 | 2018-08-15 |  | 621d |  | start no earlier than 2018-02-15 | Standard | 1040h | P000100027 |
| 10 | 3.5 | Intel Cascade Lake QS Avail Range |  | 133d | 2018-05-15 | 2018-11-15 |  | 555d |  | start no earlier than 2018-05-15 | Standard | 1064h | P000100028 |
| 11 | 3.6 | Intel Cascade Lake Production Avail Range |  | 121d | 2018-06-29 | 2018-12-14 |  | 534d |  | start no earlier than 2018-06-29 | Standard | 968h | P000100029 |
| 13 | 3.7 | ICT Ready for DVT | milestone | 0d | 2016-09-05 | 2016-09-05 |  | 1129d |  |  |  |  | P000100030 |
| 14 | 3.8 | Functional Test Ready for DVT | milestone | 0d | 2016-09-05 | 2016-09-05 |  | 1129d |  |  |  |  | P000100031 |
| 16 | 4 | **Links Out** |  | 664d | 2016-09-05 | 2019-03-21 |  | 465d |  |  |  |  | P000100032 |
| 17 | 4.1 | Europa P0-A at Engineering | milestone | 0d | 2018-05-23 | 2018-05-23 | 42 | 681d |  |  | Standard |  | P000100033 |
| 18 | 4.2 | Europa P0-B at Engineering | milestone | 0d | 2018-07-05 | 2018-07-05 | 55 | 650d |  |  | Standard |  | P000100034 |
| 19 | 4.3 | Europa P1-A at Engineering | milestone | 0d | 2018-10-03 | 2018-10-03 | 69 | 586d |  |  | Standard |  | P000100035 |
| 20 | 4.4 | Europa P1-B at Engineering | milestone | 0d | 2018-11-13 | 2018-11-13 | 82 | 557d |  |  | Standard |  | P000100036 |
| 21 | 4.5 | Europa P2-A at Engineering | milestone | 0d | 2019-02-11 | 2019-02-11 | 96 | 493d |  |  | Standard |  | P000100037 |
| 22 | 4.6 | Europa P2-B at Engineering | milestone | 0d | 2019-03-21 | 2019-03-21 | 109 | 465d |  |  | Standard |  | P000100038 |
| 23 | 4.7 | Europa GA at Engineering | milestone | 0d | 2016-09-05 | 2016-09-05 |  | 1129d |  |  | Standard |  | P000100039 |
| 25 | 4.8 | Milestone P0-A | milestone | 0d | 2018-04-30 | 2018-04-30 | 37 | 698d |  |  | Standard |  | P000100041 |
| 26 | 4.9 | Milestone P0-B | milestone | 0d | 2018-06-13 | 2018-06-13 | 50 | 667d |  |  | Standard |  | P000100042 |
| 27 | 4.10 | Milestone P1-A | milestone | 0d | 2018-09-12 | 2018-09-12 | 64 | 601d |  |  | Standard |  | P000100043 |
| 28 | 4.11 | Milestone P1-B | milestone | 0d | 2018-10-24 | 2018-10-24 | 77 | 572d |  |  | Standard |  | P000100044 |
| 29 | 4.12 | Milestone P2-A | milestone | 0d | 2019-01-21 | 2019-01-21 | 91 | 508d |  |  | Standard |  | P000100045 |
| 30 | 4.13 | Milestone P2-B | milestone | 0d | 2019-03-02 | 2019-03-02 | 104 | 479d |  |  | Standard |  | P000100046 |

| ID | WBS | Task | Type | Duration | Start | Finish | Predecessors | Total slack | Free slack | Resources | Work | Text14 | Text15 |
| --- | --- | --- | --- | --- | --- | --- | --- | --- | --- | --- | --- | --- | --- |
| 32 | 5 | **Europa Platform** |  | 357d | 2018-01-01 | 2019-05-14 |  | 427d |  |  | 7192h | P000100047 |  |
| 33 | 5.1 | **Europa Platform P0** |  | 172d | 2018-01-01 | 2018-08-28 |  | 428d |  |  | 2872h | P000100048 |  |
| 34 | 5.1.1 | Design |  | 89d | 2018-01-01 | 2018-04-13 | 6 | 427d | 0d | JDM-Asia | 712h | P000100049 |  |
| 35 | 5.1.2 | **Europa P0-A build** |  | 102d | 2018-02-23 | 2018-07-16 |  | 463d |  |  | 1080h | P000100050 |  |
| 36 | 5.1.2.1 | Europa P0-A Material Purchase |  | 47d | 2018-02-23 | 2018-05-01 | 38SF | 698d |  | JDM-US | 376h | P000100051 | Europa:P0-A:MatlPurch |
| 37 | 5.1.2.2 | Europa P0-A Fabout |  | 11d | 2018-04-16 | 2018-04-30 | 34 | 427d | 0d | Company-US | 88h | P000100052 | Europa:P0-A:Fabout |
| 38 | 5.1.2.3 | Europa P0-A SMT |  | 5d | 2018-05-01 | 2018-05-07 | 37 | 427d | 0d | JDM-US | 40h | P000100053 | Europa:P0-A:SMT |
| 39 | 5.1.2.4 | Europa P0-A Assembly |  | 5d | 2018-05-08 | 2018-05-14 | 38 | 427d | 0d | JDM-US | 40h | P000100054 | Europa:P0-A:Assembly |
| 40 | 5.1.2.5 | Europa P0-A Test |  | 3d | 2018-05-15 | 2018-05-17 | 39 | 427d | 0d | JDM-US | 24h | P000100055 | Europa:P0-A:Test |
| 41 | 5.1.2.6 | Europa P0-A Ship |  | 4d | 2018-05-18 | 2018-05-23 | 40 | 427d | 0d | Standard | 32h | P000100056 |  |
| 42 | 5.1.2.7 | Europa P0-A AtEng | milestone | 0d | 2018-05-23 | 2018-05-23 | 41 | 427d | 0d | Company-US |  | P000100057 | Europa:P0-A:AtEng |
| 43 | 5.1.2.8 | Europa P0-A Bringup |  | 14d | 2018-05-24 | 2018-06-12 | 42 | 427d | 0d | Company-US | 112h | P000100058 |  |
| 44 | 5.1.2.9 | Europa P0-A Validation / EVT Testing |  | 24d | 2018-06-13 | 2018-07-16 | 43 | 643d | 0d | Company-US | 192h | P000100059 |  |
| 45 | 5.1.2.10 | Milestone EVT | milestone | 0d | 2018-07-16 | 2018-07-16 | 44 | 643d |  | Company-US |  | P000100060 |  |
| 46 | 5.1.2.11 | Europa P0-A Spin placeholder |  | 22d | 2018-06-13 | 2018-07-12 | 43 | 645d |  | JDM-US | 176h | P000100061 |  |
| 48 | 5.1.3 | **Europa P0-B build** |  | 102d | 2018-04-09 | 2018-08-28 |  | 474d |  |  | 1080h | P000100062 |  |
| 49 | 5.1.3.1 | Europa P0-B Material Purchase |  | 47d | 2018-04-09 | 2018-06-13 | 51SF | 667d |  | JDM-US | 376h | P000100063 | Europa:P0-B:MatlPurch |
| 50 | 5.1.3.2 | Europa P0-B Fabout |  | 11d | 2018-05-29 | 2018-06-13 | 51SF | 667d | 0d | Company-US | 88h | P000100064 | Europa:P0-B:Fabout |
| 51 | 5.1.3.3 | Europa P0-B SMT |  | 5d | 2018-06-13 | 2018-06-19 | 43 | 427d | 0d | JDM-US | 40h | P000100065 | Europa:P0-B:SMT |
| 52 | 5.1.3.4 | Europa P0-B Assembly |  | 5d | 2018-06-20 | 2018-06-26 | 51 | 427d | 0d | JDM-US | 40h | P000100066 | Europa:P0-B:Assembly |
| 53 | 5.1.3.5 | Europa P0-B Test |  | 3d | 2018-06-27 | 2018-06-29 | 52 | 427d | 0d | JDM-US | 24h | P000100067 | Europa:P0-B:Test |
| 54 | 5.1.3.6 | Europa P0-B Ship |  | 4d | 2018-07-02 | 2018-07-05 | 53 | 427d | 0d | Standard | 32h | P000100068 |  |
| 55 | 5.1.3.7 | Europa P0-B AtEng | milestone | 0d | 2018-07-05 | 2018-07-05 | 54 | 427d | 0d | Company-US |  | P000100069 | Europa:P0-B:AtEng |
| 56 | 5.1.3.8 | Europa P0-B Bringup |  | 14d | 2018-07-06 | 2018-07-25 | 55 | 427d | 0d | Company-US | 112h | P000100070 |  |
| 57 | 5.1.3.9 | Europa P0-B Validation / EVT Testing |  | 24d | 2018-07-26 | 2018-08-28 | 56 | 427d | 0d | Company-US | 192h | P000100071 |  |
| 58 | 5.1.3.10 | Milestone EVT | milestone | 0d | 2018-08-28 | 2018-08-28 | 57 | 427d | 0d | Company-US |  | P000100072 |  |
| 59 | 5.1.3.11 | Europa P0-B Spin placeholder |  | 22d | 2018-07-26 | 2018-08-24 | 56 | 614d |  | JDM-US | 176h | P000100073 |  |

| ID | WBS | Task | Type | Duration | Start | Finish | Predecessors | Total slack | Free slack | Resources | Work | Text14 | Text15 |
| --- | --- | --- | --- | --- | --- | --- | --- | --- | --- | --- | --- | --- | --- |
| 61 | 5.2 | **Europa Platform P1** |  | 121d | 2018-07-20 | 2019-01-04 |  | 455d |  |  | 2160h | P000100074 |  |
| 62 | 5.2.1 | **Europa P1-A build** |  | 92d | 2018-07-20 | 2018-11-26 |  | 455d |  |  | 1080h | P000100075 |  |
| 63 | 5.2.1.1 | Europa P1-A Material Purchase |  | 47d | 2018-07-20 | 2018-09-13 | 65SF | 601d |  | JDM-Asia | 376h | P000100076 | Europa:P1-A:MatlPurch |
| 64 | 5.2.1.2 | Europa P1-A Fabout |  | 11d | 2018-08-29 | 2018-09-12 | 58 | 427d | 0d | Company-US | 88h | P000100077 | Europa:P1-A:Fabout |
| 65 | 5.2.1.3 | Europa P1-A SMT |  | 5d | 2018-09-13 | 2018-09-18 | 64 | 427d | 0d | JDM-Asia | 40h | P000100078 | Europa:P1-A:SMT |
| 66 | 5.2.1.4 | Europa P1-A Assembly |  | 5d | 2018-09-19 | 2018-09-24 | 65 | 427d | 0d | JDM-Asia | 40h | P000100079 | Europa:P1-A:Assembly |
| 67 | 5.2.1.5 | Europa P1-A Test |  | 3d | 2018-09-25 | 2018-09-27 | 66 | 426d | 0d | JDM-Asia | 24h | P000100080 | Europa:P1-A:Test |
| 68 | 5.2.1.6 | Europa P1-A Ship |  | 4d | 2018-09-28 | 2018-10-03 | 67 | 426d | 0d | Standard | 32h | P000100081 |  |
| 69 | 5.2.1.7 | Europa P1-A AtEng | milestone | 0d | 2018-10-03 | 2018-10-03 | 68 | 426d | 0d | Company-US |  | P000100082 | Europa:P1-A:AtEng |
| 70 | 5.2.1.8 | Europa P1-A Bringup |  | 14d | 2018-10-04 | 2018-10-23 | 69 | 426d | 0d | Company-US | 112h | P000100083 |  |
| 71 | 5.2.1.9 | Europa P1-A Validation / EVT Testing |  | 24d | 2018-10-24 | 2018-11-26 | 70 | 548d | 0d | Company-US | 192h | P000100084 |  |
| 72 | 5.2.1.10 | Milestone EVT | milestone | 0d | 2018-11-26 | 2018-11-26 | 71 | 548d |  | Company-US |  | P000100085 |  |
| 73 | 5.2.1.11 | Europa P1-A Spin placeholder |  | 22d | 2018-10-24 | 2018-11-17 | 70 | 553d |  | JDM-Asia | 176h | P000100086 |  |
| 75 | 5.2.2 | **Europa P1-B build** |  | 92d | 2018-08-30 | 2019-01-04 |  | 465d |  |  | 1080h | P000100087 |  |
| 76 | 5.2.2.1 | Europa P1-B Material Purchase |  | 47d | 2018-08-30 | 2018-10-24 | 78SF | 572d |  | JDM-Asia | 376h | P000100088 | Europa:P1-B:MatlPurch |
| 77 | 5.2.2.2 | Europa P1-B Fabout |  | 11d | 2018-10-09 | 2018-10-24 | 78SF | 572d | 0d | Company-US | 88h | P000100089 | Europa:P1-B:Fabout |
| 78 | 5.2.2.3 | Europa P1-B SMT |  | 5d | 2018-10-24 | 2018-10-29 | 70 | 426d | 0d | JDM-Asia | 40h | P000100090 | Europa:P1-B:SMT |
| 79 | 5.2.2.4 | Europa P1-B Assembly |  | 5d | 2018-10-30 | 2018-11-03 | 78 | 426d | 0d | JDM-Asia | 40h | P000100091 | Europa:P1-B:Assembly |
| 80 | 5.2.2.5 | Europa P1-B Test |  | 3d | 2018-11-05 | 2018-11-07 | 79 | 426d | 0d | JDM-Asia | 24h | P000100092 | Europa:P1-B:Test |
| 81 | 5.2.2.6 | Europa P1-B Ship |  | 4d | 2018-11-08 | 2018-11-13 | 80 | 426d | 0d | Standard | 32h | P000100093 |  |
| 82 | 5.2.2.7 | Europa P1-B AtEng | milestone | 0d | 2018-11-13 | 2018-11-13 | 81 | 426d | 0d | Company-US |  | P000100094 | Europa:P1-B:AtEng |
| 83 | 5.2.2.8 | Europa P1-B Bringup |  | 14d | 2018-11-14 | 2018-12-03 | 82 | 426d | 0d | Company-US | 112h | P000100095 |  |
| 84 | 5.2.2.9 | Europa P1-B Validation / EVT Testing |  | 24d | 2018-12-04 | 2019-01-04 | 83 | 426d | 0d | Company-US | 192h | P000100096 |  |
| 85 | 5.2.2.10 | Milestone EVT | milestone | 0d | 2019-01-04 | 2019-01-04 | 84 | 426d | 0d | Company-US |  | P000100097 |  |
| 86 | 5.2.2.11 | Europa P1-B Spin placeholder |  | 22d | 2018-12-04 | 2018-12-28 | 83 | 524d |  | JDM-Asia | 176h | P000100098 |  |

| ID | WBS | Task | Type | Duration | Start | Finish | Predecessors | Total slack | Free slack | Resources | Work | Text14 | Text15 |
| --- | --- | --- | --- | --- | --- | --- | --- | --- | --- | --- | --- | --- | --- |
| 88 | 5.3 | **Europa Platform P2** |  | 120d | 2018-11-28 | 2019-05-14 |  | 427d |  |  | 2160h | P000100173 |  |
| 89 | 5.3.1 | **Europa P2-A build** |  | 92d | 2018-11-28 | 2019-04-04 |  | 454d |  |  | 1080h | P000100174 |  |
| 90 | 5.3.1.1 | Europa P2-A Material Purchase |  | 47d | 2018-11-28 | 2019-01-22 | 92SF | 508d |  | JDM-Asia | 376h | P000100175 | Europa:P2-A:MatlPurch |
| 91 | 5.3.1.2 | Europa P2-A Fabout |  | 11d | 2019-01-07 | 2019-01-21 | 85 | 426d | 0d | Company-US | 88h | P000100176 | Europa:P2-A:Fabout |
| 92 | 5.3.1.3 | Europa P2-A SMT |  | 5d | 2019-01-22 | 2019-01-26 | 91 | 426d | 0d | JDM-Asia | 40h | P000100177 | Europa:P2-A:SMT |
| 93 | 5.3.1.4 | Europa P2-A Assembly |  | 5d | 2019-01-28 | 2019-02-01 | 92 | 425d | 0d | JDM-Asia | 40h | P000100178 | Europa:P2-A:Assembly |
| 94 | 5.3.1.5 | Europa P2-A Test |  | 3d | 2019-02-02 | 2019-02-05 | 93 | 425d | 0d | JDM-Asia | 24h | P000100179 | Europa:P2-A:Test |
| 95 | 5.3.1.6 | Europa P2-A Ship |  | 4d | 2019-02-06 | 2019-02-11 | 94 | 426d | 0d | Standard | 32h | P000100180 |  |
| 96 | 5.3.1.7 | Europa P2-A AtEng | milestone | 0d | 2019-02-11 | 2019-02-11 | 95 | 426d | 0d | Company-US |  | P000100181 | Europa:P2-A:AtEng |
| 97 | 5.3.1.8 | Europa P2-A Bringup |  | 14d | 2019-02-12 | 2019-03-01 | 96 | 426d | 0d | Company-US | 112h | P000100182 |  |
| 98 | 5.3.1.9 | Europa P2-A Validation / DVT Testing |  | 24d | 2019-03-04 | 2019-04-04 | 97 | 455d | 0d | Company-US | 192h | P000100183 |  |
| 99 | 5.3.1.10 | Milestone DVT | milestone | 0d | 2019-04-04 | 2019-04-04 | 98 | 455d |  | Company-US |  | P000100184 |  |
| 100 | 5.3.1.11 | Europa P2-A Spin placeholder |  | 22d | 2019-03-02 | 2019-03-27 | 97 | 460d |  | JDM-Asia | 176h | P000100185 |  |
| 102 | 5.3.2 | **Europa P2-B build** |  | 92d | 2019-01-07 | 2019-05-14 |  | 427d |  |  | 1080h | P000100186 |  |
| 103 | 5.3.2.1 | Europa P2-B Material Purchase |  | 47d | 2019-01-07 | 2019-03-02 | 105SF | 479d |  | JDM-Asia | 376h | P000100187 | Europa:P2-B:MatlPurch |
| 104 | 5.3.2.2 | Europa P2-B Fabout |  | 11d | 2019-02-15 | 2019-03-02 | 105SF | 479d | 0d | Company-US | 88h | P000100188 | Europa:P2-B:Fabout |
| 105 | 5.3.2.3 | Europa P2-B SMT |  | 5d | 2019-03-02 | 2019-03-07 | 97 | 426d | 0d | JDM-Asia | 40h | P000100189 | Europa:P2-B:SMT |
| 106 | 5.3.2.4 | Europa P2-B Assembly |  | 5d | 2019-03-08 | 2019-03-13 | 105 | 426d | 0d | JDM-Asia | 40h | P000100190 | Europa:P2-B:Assembly |
| 107 | 5.3.2.5 | Europa P2-B Test |  | 3d | 2019-03-14 | 2019-03-16 | 106 | 427d | 0d | JDM-Asia | 24h | P000100191 | Europa:P2-B:Test |
| 108 | 5.3.2.6 | Europa P2-B Ship |  | 4d | 2019-03-18 | 2019-03-21 | 107 | 427d | 0d | Standard | 32h | P000100192 |  |
| 109 | 5.3.2.7 | Europa P2-B AtEng | milestone | 0d | 2019-03-21 | 2019-03-21 | 108 | 427d | 0d | Company-US |  | P000100193 | Europa:P2-B:AtEng |
| 110 | 5.3.2.8 | Europa P2-B Bringup |  | 14d | 2019-03-22 | 2019-04-10 | 109 | 427d | 0d | Company-US | 112h | P000100194 |  |
| 111 | 5.3.2.9 | Europa P2-B Validation / DVT Testing |  | 24d | 2019-04-11 | 2019-05-14 | 110 | 427d | 0d | Company-US | 192h | P000100195 |  |
| 112 | 5.3.2.10 | Milestone DVT | milestone | 0d | 2019-05-14 | 2019-05-14 | 111 | 427d |  | Company-US |  | P000100196 |  |
| 113 | 5.3.2.11 | Europa P2-B Spin placeholder |  | 22d | 2019-04-11 | 2019-05-06 | 110 | 432d |  | JDM-Asia | 176h | P000100197 |  |
