# M0005

Schedule from MS Project, 2016-09-05 to 2019-05-14.
rmbpublic@comcast.net
Entire work, Power Operational Intelligence ("PowerOpI") PowerQueryTool / Copyright (c) 2020 Richard M. Bixler / All Rights Reserved / rmbpublic@comcast.net / www.softtoyssoftware.com

## Calendars

- Standard-17: Mon-Fri 08:00-12:00, 13:00-17:00; Sat-Sun off.

## Resources

| Resource |
| --- |
| Company-US |
| JDM-US |
| JDM-Asia |
| Standard |

## Schedule

| ID | WBS | Task | Type | Duration | Start | Finish | Predecessors | Total slack | Free slack | Constraint | Resources | Work | Text14 | Text15 |
| --- | --- | --- | --- | --- | --- | --- | --- | --- | --- | --- | --- | --- | --- | --- |
| 1 | 1 | Last ModuleTaskUID | milestone | 0d | 2016-09-05 | 2016-09-05 |  | 702d |  |  |  |  | P000100100 |  |
| 2 | 2 | M0004 ModuleName "Io-Jun" | milestone | 0d | 2016-09-05 | 2016-09-05 |  | 702d |  |  |  |  | P000100101 |  |
| 4 | 3 | **Links In** |  | 345d | 2016-09-05 | 2018-01-01 |  | 346d |  |  |  |  | P000100102 |  |
| 5 | 3.1 | Begin Funded Work | milestone | 0d | 2018-01-01 | 2018-01-01 |  | 1d | 0d | start no earlier than 2018-01-01 |  |  |  |  |
| 6 | 3.2 | Begin JDM Funded Work | milestone | 0d | 2018-01-01 | 2018-01-01 | 5 | 1d | 0d |  | JDM-Asia |  | P000100103 |  |
| 8 | 3.3 | ICT Ready for DVT | milestone | 0d | 2016-09-05 | 2016-09-05 |  | 702d |  |  |  |  | P000100104 |  |
| 9 | 3.4 | Functional Test Ready for DVT | milestone | 0d | 2016-09-05 | 2016-09-05 |  | 702d |  |  |  |  | P000100105 |  |
| 11 | 4 | **Links Out** |  | 664d | 2016-09-05 | 2019-03-21 |  | 38d |  |  |  |  | P000100107 |  |
| 12 | 4.1 | Io P0-A at Engineering | milestone | 0d | 2018-05-23 | 2018-05-23 | 37 | 254d |  |  | Standard |  | P000100108 | Io:EVT:AtEngineering |
| 13 | 4.2 | Io P0-B at Engineering | milestone | 0d | 2018-07-05 | 2018-07-05 | 50 | 223d |  |  | Standard |  | P000100109 | Io:CDVT:AtEngineering |
| 14 | 4.3 | Io P1-A at Engineering | milestone | 0d | 2018-10-03 | 2018-10-03 | 64 | 159d |  |  | Standard |  | P000100110 | Io:DVT-1:AtEngineering |
| 15 | 4.4 | Io P1-B at Engineering | milestone | 0d | 2018-11-13 | 2018-11-13 | 77 | 130d |  |  | Standard |  | P000100111 | Io:DVT-2:AtEngineering |
| 16 | 4.5 | Io P2-A at Engineering | milestone | 0d | 2019-02-11 | 2019-02-11 | 91 | 66d |  |  | Standard |  | P000100112 | Io:MVT:AtEngineering |
| 17 | 4.6 | Io P2-B at Engineering | milestone | 0d | 2019-03-21 | 2019-03-21 | 104 | 38d |  |  | Standard |  | P000100113 | Io:DMT:AtEngineering |
| 18 | 4.7 | Io GA at Engineering | milestone | 0d | 2016-09-05 | 2016-09-05 |  | 702d |  |  | Standard |  | P000100114 | Io:GA:AtEngineering |
| 20 | 4.8 | Milestone P0-A | milestone | 0d | 2018-04-30 | 2018-04-30 | 32 | 271d |  |  | Standard |  | P000100115 |  |
| 21 | 4.9 | Milestone P0-B | milestone | 0d | 2018-06-13 | 2018-06-13 | 45 | 240d |  |  | Standard |  | P000100116 |  |
| 22 | 4.10 | Milestone P1-A | milestone | 0d | 2018-09-12 | 2018-09-12 | 59 | 174d |  |  | Standard |  | P000100117 |  |
| 23 | 4.11 | Milestone P1-B | milestone | 0d | 2018-10-24 | 2018-10-24 | 72 | 145d |  |  | Standard |  | P000100118 |  |
| 24 | 4.12 | Milestone P2-A | milestone | 0d | 2019-01-21 | 2019-01-21 | 86 | 81d |  |  | Standard |  | P000100119 |  |
| 25 | 4.13 | Milestone P2-B | milestone | 0d | 2019-03-02 | 2019-03-02 | 99 | 52d |  |  | Standard |  | P000100120 |  |
| 27 | 5 | **Io Platform** |  | 357d | 2018-01-01 | 2019-05-14 |  | 0d |  |  |  | 7192h | P000100121 |  |
| 28 | 5.1 | **Io Platform P0** |  | 172d | 2018-01-01 | 2018-08-28 |  | 1d |  |  |  | 2872h | P000100122 |  |
| 29 | 5.1.1 | Design |  | 89d | 2018-01-01 | 2018-04-13 | 6 | 0d |  |  | JDM-Asia | 712h | P000100123 |  |

| ID | WBS | Task | Type | Duration | Start | Finish | Predecessors | Total slack | Free slack | Resources | Work | Text14 | Text15 |
| --- | --- | --- | --- | --- | --- | --- | --- | --- | --- | --- | --- | --- | --- |
| 30 | 5.1.2 | **Io P0 build** |  | 102d | 2018-02-23 | 2018-07-16 |  | 36d |  |  | 1080h | P000100124 |  |
| 31 | 5.1.2.1 | Io P0-A Material Purchase |  | 47d | 2018-02-23 | 2018-05-01 | 33SF | 271d |  | JDM-US | 376h | P000100125 | Io:P0-A:MatlPurch |
| 32 | 5.1.2.2 | Io P0-A Fabout |  | 11d | 2018-04-16 | 2018-04-30 | 29 | 0d |  | Company-US | 88h | P000100126 | Io:P0-A:Fabout |
| 33 | 5.1.2.3 | Io P0-A SMT |  | 5d | 2018-05-01 | 2018-05-07 | 32 | 0d |  | JDM-US | 40h | P000100127 | Io:P0-A:SMT |
| 34 | 5.1.2.4 | Io P0-A Assembly |  | 5d | 2018-05-08 | 2018-05-14 | 33 | 0d |  | JDM-US | 40h | P000100128 | Io:P0-A:Assembly |
| 35 | 5.1.2.5 | Io P0-A Test |  | 3d | 2018-05-15 | 2018-05-17 | 34 | 0d |  | JDM-US | 24h | P000100129 | Io:P0-A:Test |
| 36 | 5.1.2.6 | Io P0-A Ship |  | 4d | 2018-05-18 | 2018-05-23 | 35 | 0d |  | Standard | 32h | P000100130 |  |
| 37 | 5.1.2.7 | Io P0-A AtEng | milestone | 0d | 2018-05-23 | 2018-05-23 | 36 | 0d |  | Company-US |  | P000100131 | Io:P0-A:AtEng |
| 38 | 5.1.2.8 | Io P0-A Bringup |  | 14d | 2018-05-24 | 2018-06-12 | 37 | 0d |  | Company-US | 112h | P000100132 |  |
| 39 | 5.1.2.9 | Io P0-A Validation / EVT Testing |  | 24d | 2018-06-13 | 2018-07-16 | 38 | 216d | 0d | Company-US | 192h | P000100133 |  |
| 40 | 5.1.2.10 | Milestone EVT | milestone | 0d | 2018-07-16 | 2018-07-16 | 39 | 216d |  | Company-US |  | P000100134 |  |
| 41 | 5.1.2.11 | Io P0-A Spin placeholder |  | 22d | 2018-06-13 | 2018-07-12 | 38 | 218d |  | JDM-US | 176h | P000100135 |  |
| 43 | 5.1.3 | **Io P0-B build** |  | 102d | 2018-04-09 | 2018-08-28 |  | 47d |  |  | 1080h | P000100136 |  |
| 44 | 5.1.3.1 | Io P0-B Material Purchase |  | 47d | 2018-04-09 | 2018-06-13 | 46SF | 240d |  | JDM-US | 376h | P000100137 | Io:P0-B:MatlPurch |
| 45 | 5.1.3.2 | Io P0-B Fabout |  | 11d | 2018-05-29 | 2018-06-13 | 46SF | 240d | 0d | Company-US | 88h | P000100138 | Io:P0-B:Fabout |
| 46 | 5.1.3.3 | Io P0-B SMT |  | 5d | 2018-06-13 | 2018-06-19 | 38 | 0d |  | JDM-US | 40h | P000100139 | Io:P0-B:SMT |
| 47 | 5.1.3.4 | Io P0-B Assembly |  | 5d | 2018-06-20 | 2018-06-26 | 46 | 0d |  | JDM-US | 40h | P000100140 | Io:P0-B:Assembly |
| 48 | 5.1.3.5 | Io P0-B Test |  | 3d | 2018-06-27 | 2018-06-29 | 47 | 0d |  | JDM-US | 24h | P000100141 | Io:P0-B:Test |
| 49 | 5.1.3.6 | Io P0-B Ship |  | 4d | 2018-07-02 | 2018-07-05 | 48 | 0d |  | Standard | 32h | P000100142 |  |
| 50 | 5.1.3.7 | Io P0-B AtEng | milestone | 0d | 2018-07-05 | 2018-07-05 | 49 | 0d |  | Company-US |  | P000100143 | Io:P0-B:AtEng |
| 51 | 5.1.3.8 | Io P0-B Bringup |  | 14d | 2018-07-06 | 2018-07-25 | 50 | 0d |  | Company-US | 112h | P000100144 |  |
| 52 | 5.1.3.9 | Io P0-B Validation / EVT Testing |  | 24d | 2018-07-26 | 2018-08-28 | 51 | 0d |  | Company-US | 192h | P000100145 |  |
| 53 | 5.1.3.10 | Milestone EVT | milestone | 0d | 2018-08-28 | 2018-08-28 | 52 | 0d |  | Company-US |  | P000100146 |  |
| 54 | 5.1.3.11 | Io P0-B Spin placeholder |  | 22d | 2018-07-26 | 2018-08-24 | 51 | 187d |  | JDM-US | 176h | P000100147 |  |

| ID | WBS | Task | Type | Duration | Start | Finish | Predecessors | Total slack | Free slack | Resources | Work | Text14 | Text15 |
| --- | --- | --- | --- | --- | --- | --- | --- | --- | --- | --- | --- | --- | --- |
| 56 | 5.2 | **Io Platform P1** |  | 121d | 2018-07-20 | 2019-01-04 |  | 28d |  |  | 2160h | P000100148 |  |
| 57 | 5.2.1 | **Io P1-A build** |  | 92d | 2018-07-20 | 2018-11-26 |  | 28d |  |  | 1080h | P000100149 |  |
| 58 | 5.2.1.1 | Io P1-A Material Purchase |  | 47d | 2018-07-20 | 2018-09-13 | 60SF | 174d |  | JDM-Asia | 376h | P000100150 | Io:P1-A:MatlPurch |
| 59 | 5.2.1.2 | Io P1-A Fabout |  | 11d | 2018-08-29 | 2018-09-12 | 53 | 0d |  | Company-US | 88h | P000100151 | Io:P1-A:Fabout |
| 60 | 5.2.1.3 | Io P1-A SMT |  | 5d | 2018-09-13 | 2018-09-18 | 59 | 0d |  | JDM-Asia | 40h | P000100152 | Io:P1-A:SMT |
| 61 | 5.2.1.4 | Io P1-A Assembly |  | 5d | 2018-09-19 | 2018-09-24 | 60 | 0d |  | JDM-Asia | 40h | P000100153 | Io:P1-A:Assembly |
| 62 | 5.2.1.5 | Io P1-A Test |  | 3d | 2018-09-25 | 2018-09-27 | 61 | 0d |  | JDM-Asia | 24h | P000100154 | Io:P1-A:Test |
| 63 | 5.2.1.6 | Io P1-A Ship |  | 4d | 2018-09-28 | 2018-10-03 | 62 | 0d |  | Standard | 32h | P000100155 |  |
| 64 | 5.2.1.7 | Io P1-A AtEng | milestone | 0d | 2018-10-03 | 2018-10-03 | 63 | 0d |  | Company-US |  | P000100156 | Io:P1-A:AtEng |
| 65 | 5.2.1.8 | Io P1-A Bringup |  | 14d | 2018-10-04 | 2018-10-23 | 64 | 0d |  | Company-US | 112h | P000100157 |  |
| 66 | 5.2.1.9 | Io P1-A Validation / EVT Testing |  | 24d | 2018-10-24 | 2018-11-26 | 65 | 121d | 0d | Company-US | 192h | P000100158 |  |
| 67 | 5.2.1.10 | Milestone EVT | milestone | 0d | 2018-11-26 | 2018-11-26 | 66 | 121d |  | Company-US |  | P000100159 |  |
| 68 | 5.2.1.11 | Io P1-A Spin placeholder |  | 22d | 2018-10-24 | 2018-11-17 | 65 | 127d |  | JDM-Asia | 176h | P000100160 |  |
| 70 | 5.2.2 | **Io P1-B build** |  | 92d | 2018-08-30 | 2019-01-04 |  | 39d |  |  | 1080h | P000100161 |  |
| 71 | 5.2.2.1 | Io P1-B Material Purchase |  | 47d | 2018-08-30 | 2018-10-24 | 73SF | 145d |  | JDM-Asia | 376h | P000100162 | Io:P1-B:MatlPurch |
| 72 | 5.2.2.2 | Io P1-B Fabout |  | 11d | 2018-10-09 | 2018-10-24 | 73SF | 145d | 0d | Company-US | 88h | P000100163 | Io:P1-B:Fabout |
| 73 | 5.2.2.3 | Io P1-B SMT |  | 5d | 2018-10-24 | 2018-10-29 | 65 | 0d |  | JDM-Asia | 40h | P000100164 | Io:P1-B:SMT |
| 74 | 5.2.2.4 | Io P1-B Assembly |  | 5d | 2018-10-30 | 2018-11-03 | 73 | 0d |  | JDM-Asia | 40h | P000100165 | Io:P1-B:Assembly |
| 75 | 5.2.2.5 | Io P1-B Test |  | 3d | 2018-11-05 | 2018-11-07 | 74 | 0d |  | JDM-Asia | 24h | P000100166 | Io:P1-B:Test |
| 76 | 5.2.2.6 | Io P1-B Ship |  | 4d | 2018-11-08 | 2018-11-13 | 75 | 0d |  | Standard | 32h | P000100167 |  |
| 77 | 5.2.2.7 | Io P1-B AtEng | milestone | 0d | 2018-11-13 | 2018-11-13 | 76 | 0d |  | Company-US |  | P000100168 | Io:P1-B:AtEng |
| 78 | 5.2.2.8 | Io P1-B Bringup |  | 14d | 2018-11-14 | 2018-12-03 | 77 | 0d |  | Company-US | 112h | P000100169 |  |
| 79 | 5.2.2.9 | Io P1-B Validation / EVT Testing |  | 24d | 2018-12-04 | 2019-01-04 | 78 | 0d |  | Company-US | 192h | P000100170 |  |
| 80 | 5.2.2.10 | Milestone EVT | milestone | 0d | 2019-01-04 | 2019-01-04 | 79 | 0d |  | Company-US |  | P000100171 |  |
| 81 | 5.2.2.11 | Io P1-B Spin placeholder |  | 22d | 2018-12-04 | 2018-12-28 | 78 | 97d |  | JDM-Asia | 176h | P000100172 |  |

| ID | WBS | Task | Type | Duration | Start | Finish | Predecessors | Total slack | Free slack | Resources | Work | Text14 | Text15 |
| --- | --- | --- | --- | --- | --- | --- | --- | --- | --- | --- | --- | --- | --- |
| 83 | 5.3 | **Io Platform P2** |  | 120d | 2018-11-28 | 2019-05-14 |  | 0d |  |  | 2160h | P000100198 |  |
| 84 | 5.3.1 | **Io P2-A build** |  | 92d | 2018-11-28 | 2019-04-04 |  | 28d |  |  | 1080h | P000100199 |  |
| 85 | 5.3.1.1 | Io P2-A Material Purchase |  | 47d | 2018-11-28 | 2019-01-22 | 87SF | 81d |  | JDM-Asia | 376h | P000100200 | Io:P2-A:MatlPurch |
| 86 | 5.3.1.2 | Io P2-A Fabout |  | 11d | 2019-01-07 | 2019-01-21 | 80 | 0d |  | Company-US | 88h | P000100201 | Io:P2-A:Fabout |
| 87 | 5.3.1.3 | Io P2-A SMT |  | 5d | 2019-01-22 | 2019-01-26 | 86 | 0d |  | JDM-Asia | 40h | P000100202 | Io:P2-A:SMT |
| 88 | 5.3.1.4 | Io P2-A Assembly |  | 5d | 2019-01-28 | 2019-02-01 | 87 | 0d |  | JDM-Asia | 40h | P000100203 | Io:P2-A:Assembly |
| 89 | 5.3.1.5 | Io P2-A Test |  | 3d | 2019-02-02 | 2019-02-05 | 88 | 0d |  | JDM-Asia | 24h | P000100204 | Io:P2-A:Test |
| 90 | 5.3.1.6 | Io P2-A Ship |  | 4d | 2019-02-06 | 2019-02-11 | 89 | 0d |  | Standard | 32h | P000100205 |  |
| 91 | 5.3.1.7 | Io P2-A AtEng | milestone | 0d | 2019-02-11 | 2019-02-11 | 90 | 0d |  | Company-US |  | P000100206 | Io:P2-A:AtEng |
| 92 | 5.3.1.8 | Io P2-A Bringup |  | 14d | 2019-02-12 | 2019-03-01 | 91 | 0d |  | Company-US | 112h | P000100207 |  |
| 93 | 5.3.1.9 | Io P2-A Validation / DVT Testing |  | 24d | 2019-03-04 | 2019-04-04 | 92 | 28d | 0d | Company-US | 192h | P000100208 |  |
| 94 | 5.3.1.10 | Milestone EVT | milestone | 0d | 2019-04-04 | 2019-04-04 | 93 | 28d |  | Company-US |  | P000100209 |  |
| 95 | 5.3.1.11 | Io P2-A Spin placeholder |  | 22d | 2019-03-02 | 2019-03-27 | 92 | 34d |  | JDM-Asia | 176h | P000100210 |  |
| 97 | 5.3.2 | **Io P2-B build** |  | 92d | 2019-01-07 | 2019-05-14 |  | 0d |  |  | 1080h | P000100211 |  |
| 98 | 5.3.2.1 | Io P2-B Material Purchase |  | 47d | 2019-01-07 | 2019-03-02 | 100SF | 52d |  | JDM-Asia | 376h | P000100212 | Io:P2-B:MatlPurch |
| 99 | 5.3.2.2 | Io P2-B Fabout |  | 11d | 2019-02-15 | 2019-03-02 | 100SF | 52d | 0d | Company-US | 88h | P000100213 | Io:P2-B:Fabout |
| 100 | 5.3.2.3 | Io P2-B SMT |  | 5d | 2019-03-02 | 2019-03-07 | 92 | 0d |  | JDM-Asia | 40h | P000100214 | Io:P2-B:SMT |
| 101 | 5.3.2.4 | Io P2-B Assembly |  | 5d | 2019-03-08 | 2019-03-13 | 100 | 0d |  | JDM-Asia | 40h | P000100215 | Io:P2-B:Assembly |
| 102 | 5.3.2.5 | Io P2-B Test |  | 3d | 2019-03-14 | 2019-03-16 | 101 | 0d |  | JDM-Asia | 24h | P000100216 | Io:P2-B:Test |
| 103 | 5.3.2.6 | Io P2-B Ship |  | 4d | 2019-03-18 | 2019-03-21 | 102 | 0d |  | Standard | 32h | P000100217 |  |
| 104 | 5.3.2.7 | Io P2-B AtEng | milestone | 0d | 2019-03-21 | 2019-03-21 | 103 | 0d |  | Company-US |  | P000100218 | Io:P2-B:AtEng |
| 105 | 5.3.2.8 | Io P2-B Bringup |  | 14d | 2019-03-22 | 2019-04-10 | 104 | 0d |  | Company-US | 112h | P000100219 |  |
| 106 | 5.3.2.9 | Io P2-B Validation / DVT Testing |  | 24d | 2019-04-11 | 2019-05-14 | 105 | 0d |  | Company-US | 192h | P000100220 |  |
| 107 | 5.3.2.10 | Milestone EVT | milestone | 0d | 2019-05-14 | 2019-05-14 | 106 | 0d |  | Company-US |  | P000100221 |  |
| 108 | 5.3.2.11 | Io P2-B Spin placeholder |  | 22d | 2019-04-11 | 2019-05-06 | 105 | 6d |  | JDM-Asia | 176h | P000100222 |  |
